# Factory Facelift #4

How a schedule from MS Project changed from version to version. A marks actual dates.

## Version 1 (data date 2003-07-07, saved 2011-10-03, file Factory Facelift #4.mpp)

| ID | WBS | Task | Duration | Start | Finish | Predecessors | Complete | Total float | Constraint |
| --- | --- | --- | --- | --- | --- | --- | --- | --- | --- |
| 1 | 1 | **Factory Facelift** | 17.44d | 2004-06-18 A | 2004-07-13 |  | 93% | 0d |  |
| 2 | 1.1 | **Build Façade** | 7.5d | 2004-06-18 A | 2004-06-29 A |  | 100% |  |  |
| 3 |  | Remove old exterior | 2d | 2004-06-18 A | 2004-06-21 A |  | 100% |  |  |
| 4 |  | Erect framework | 4d | 2004-06-19 A | 2004-06-23 A | 3 | 100% |  |  |
| 5 |  | Add glasswork | 2d | 2004-06-24 A | 2004-06-25 A | 4 | 100% |  |  |
| 6 |  | Erect/paint new walls | 2d | 2004-06-26 A | 2004-06-29 A | 5 | 100% |  |  |
| 7 | 1.2 | **Landscape Garden** | 5.19d | 2004-06-30 A | 2004-07-07 A |  | 100% |  |  |
| 8 |  | Clear debris | 1d | 2004-06-30 A | 2004-06-30 A | 6 | 100% |  |  |
| 9 |  | Add topsoil | 1d | 2004-06-30 A | 2004-06-30 A | 8 | 100% |  |  |
| 10 |  | Lay lawns | 2d | 2004-07-01 A | 2004-07-05 A | 9 | 100% |  |  |
| 11 |  | Plant trees and flower beds | 2.5d | 2004-07-03 A | 2004-07-07 A | 10 | 100% |  | start no earlier than 2003-07-02 |
| 12 | 1.3 | **Erect Fountain** | 1.06d | 2004-07-10 A | 2004-07-13 |  | 33% | 0d |  |
| 13 |  | Assemble fountain | 8h | 2004-07-10 A | 2004-07-12 | 11 | 50% | 0d | finish no earlier than 2004-07-12 |
| 14 |  | Connect plumbing | 4h | 2004-07-12 | 2004-07-13 | 13 |  | 0d |  |
| 15 | 1.4 | **Erect Flagpole** | 0.38d | 2004-07-13 | 2004-07-13 |  |  | 0d |  |
| 16 |  | Construct footing | 2h | 2004-07-13 | 2004-07-13 | 14 |  | 0d |  |
| 17 |  | Attach flagpole | 1h | 2004-07-13 | 2004-07-13 | 16 |  | 0d |  |
| 18 |  | Project Completed | 0d | 2004-07-13 | 2004-07-13 | 17 |  | 0d |  |

## Version 2 (data date 2004-07-09, saved 2011-10-03, file Factory Facelift #3.mpp)

Last finish stays 2004-07-13.

Changed:

| ID | Task | Start | Finish | Duration | Complete | Other |
| --- | --- | --- | --- | --- | --- | --- |
| 1 | **Factory Facelift** | 2004-06-18 A → 2004-06-22 A (+4d) |  | 17.44d → 15.44d | 93% → 90% | constraint none → as late as possible |
| 2 | **Build Façade** | 2004-06-18 A → 2004-06-22 A (+4d) |  | 7.5d → 5.5d |  | constraint none → as late as possible |
| 3 | Remove old exterior | 2004-06-18 A → 2004-06-22 A (+4d) | 2004-06-21 A → 2004-06-23 A (+2d) |  |  |  |
| 4 | Erect framework | 2004-06-19 A → 2004-06-23 A (+4d) | 2004-06-23 A → 2004-06-25 A (+2d) |  |  |  |
| 5 | Add glasswork | 2004-06-24 A → 2004-06-25 A (+1d) | 2004-06-25 A → 2004-06-28 A (+3d) |  |  |  |
| 6 | Erect/paint new walls | 2004-06-26 A → 2004-06-28 A (+2d) |  |  |  | resources B & G Construction; Paint [0.28 Gallons] → B & G Construction; Paint [50 Gallons] |
| 7 | **Landscape Garden** |  | 2004-07-07 A → 2004-07-08 A (+1d) | 5.19d → 6.19d |  | constraint none → as late as possible |
| 9 | Add topsoil | 2004-06-30 A → 2004-07-02 A (+2d) | 2004-06-30 A → 2004-07-05 A (+5d) |  |  |  |
| 10 | Lay lawns | 2004-07-01 A → 2004-07-05 A (+4d) | 2004-07-05 A → 2004-07-06 A (+1d) |  |  |  |
| 11 | Plant trees and flower beds | 2004-07-03 A → 2004-07-06 A (+3d) | 2004-07-07 A → 2004-07-08 A (+1d) |  |  |  |
| 12 | **Erect Fountain** | 2004-07-10 A → 2004-07-12 (+2d) |  |  | 33% → 0% | constraint none → as late as possible |
| 13 | Assemble fountain | 2004-07-10 A → 2004-07-12 (+2d) |  |  | 50% → 0% | constraint finish no earlier than 2004-07-12 → start no earlier than 2004-07-12 |
| 15 | **Erect Flagpole** |  |  |  |  | constraint none → as late as possible |

## Version 3 (saved 2011-10-03, file Factory Facelift #2.mpp)

Last finish 2004-07-13 → 2004-07-09 (-4d). Complete tasks 8 → 0.

Changed:

| ID | Task | Start | Finish | Duration | Complete | Total float | Other |
| --- | --- | --- | --- | --- | --- | --- | --- |
| 1 | **Factory Facelift** | 2004-06-22 A → 2004-06-16 (-6d) | 2004-07-13 → 2004-07-09 (-4d) | 15.44d → 17.5d | 90% → 0% |  | constraint as late as possible → none; baseline start 2003-06-16 → none; baseline finish 2003-07-09 → none |
| 2 | **Build Façade** | 2004-06-22 A → 2004-06-16 (-6d) | 2004-06-29 A → 2004-06-25 (-4d) | 5.5d → 7.06d | 100% → 0% | none → 1.38d | constraint as late as possible → none; baseline start 2003-06-16 → none; baseline finish 2003-06-25 → none |
| 3 | Remove old exterior | 2004-06-22 A → 2004-06-16 (-6d) | 2004-06-23 A → 2004-06-17 (-6d) |  | 100% → 0% | none → 1.5d | baseline start 2003-06-16 → none; baseline finish 2003-06-17 → none |
| 4 | Erect framework | 2004-06-23 A → 2004-06-17 (-6d) | 2004-06-25 A → 2004-06-21 (-4d) | 4d → 3d | 100% → 0% | none → 1.12d | baseline start 2003-06-17 → none; baseline finish 2003-06-19 → none |
| 5 | Add glasswork | 2004-06-25 A → 2004-06-21 (-4d) | 2004-06-28 A → 2004-06-23 (-5d) |  | 100% → 0% | none → 1.12d | baseline start 2003-06-19 → none; baseline finish 2003-06-23 → none |
| 6 | Erect/paint new walls | 2004-06-28 A → 2004-06-23 (-5d) | 2004-06-29 A → 2004-06-25 (-4d) |  | 100% → 0% | none → 1.12d | baseline start 2003-06-23 → none; baseline finish 2003-06-25 → none |
| 7 | **Landscape Garden** | 2004-06-30 A → 2004-06-28 (-2d) | 2004-07-08 A → 2004-07-07 (-1d) | 6.19d → 8d | 100% → 0% | none → 0d | constraint as late as possible → none; baseline start 2003-06-25 → none; baseline finish 2003-07-07 → none |
| 8 | Clear debris | 2004-06-30 A → 2004-06-28 (-2d) | 2004-06-30 A → 2004-06-28 (-2d) |  | 100% → 0% | none → 0.31d | baseline start 2003-06-25 → none; baseline finish 2003-06-25 → none |
| 9 | Add topsoil | 2004-07-02 A → 2004-06-28 (-4d) | 2004-07-05 A → 2004-06-29 (-6d) |  | 100% → 0% | none → 0.31d | baseline start 2003-06-26 → none; baseline finish 2003-06-26 → none |
| 10 | Lay lawns | 2004-07-05 A → 2004-06-29 (-6d) | 2004-07-06 A → 2004-07-01 (-5d) |  | 100% → 0% | none → 0.31d | baseline start 2003-06-26 → none; baseline finish 2003-07-01 → none |
| 11 | Plant trees and flower beds | 2004-07-06 A → 2004-07-05 (-1d) | 2004-07-08 A → 2004-07-07 (-1d) | 2.5d → 3.25d | 100% → 0% | none → 0d | constraint start no earlier than 2003-07-02 → start no earlier than 2004-07-02; baseline start 2003-07-02 → none; baseline finish 2003-07-07 → none |
| 12 | **Erect Fountain** | 2004-07-12 → 2004-07-07 (-5d) | 2004-07-13 → 2004-07-09 (-4d) | 1.06d → 1.19d |  |  | constraint as late as possible → none; baseline start 2003-07-07 → none; baseline finish 2003-07-09 → none |
| 13 | Assemble fountain | 2004-07-12 → 2004-07-07 (-5d) | 2004-07-12 → 2004-07-08 (-4d) | 8h → 12h |  |  | constraint start no earlier than 2004-07-12 → none; baseline start 2003-07-07 → none; baseline finish 2003-07-08 → none |
| 14 | Connect plumbing | 2004-07-12 → 2004-07-08 (-4d) | 2004-07-13 → 2004-07-09 (-4d) |  |  | 2.06d → 0d | baseline start 2003-07-08 → none; baseline finish 2003-07-09 → none |
| 15 | **Erect Flagpole** | 2004-07-13 → 2004-07-09 (-4d) | 2004-07-13 → 2004-07-09 (-4d) | 0.38d → 0.31d |  |  | constraint as late as possible → none; baseline start 2003-07-09 → none; baseline finish 2003-07-09 → none |
| 16 | Construct footing | 2004-07-13 → 2004-07-09 (-4d) | 2004-07-13 → 2004-07-09 (-4d) |  |  | 2.56d → 0d | baseline start 2003-07-09 → none; baseline finish 2003-07-09 → none |
| 17 | Attach flagpole | 2004-07-13 → 2004-07-09 (-4d) | 2004-07-13 → 2004-07-09 (-4d) |  |  | 2.56d → 0d | baseline start 2003-07-09 → none; baseline finish 2003-07-09 → none |
| 18 | Project Completed | 2004-07-13 → 2004-07-09 (-4d) | 2004-07-13 → 2004-07-09 (-4d) |  |  | 2.56d → 0d | baseline start 2003-07-09 → none; baseline finish 2003-07-09 → none |
